# 总控计划2

Schedule from MS Project, 2004-10-01 to 2006-10-19.
cscec

## Calendars

- 标准: Mon-Sun 08:00-12:00, 13:00-17:00.

## Schedule

| ID | WBS | Task | Duration | Start | Finish | Predecessors | Baseline start | Baseline finish | Baseline duration | Total slack | Free slack | Constraint |
| --- | --- | --- | --- | --- | --- | --- | --- | --- | --- | --- | --- | --- |
| 1 | 1 | **前期准备工作** | 56d | 2004-10-01 | 2004-11-25 |  |  |  |  | 693d |  |  |
| 2 | 1.1 | 测量钉桩 | 2d | 2004-10-01 | 2004-10-02 |  |  |  |  | 747d |  | start no earlier than 2004-10-01 |
| 3 | 1.2 | 1#、3#、5#塔吊基础 | 9d | 2004-10-08 | 2004-10-16 |  |  |  |  | 718d | 0d | start no earlier than 2004-10-08 |
| 4 | 1.3 | 1#、3#、5#塔吊安装 | 9d | 2004-10-23 | 2004-10-31 | 3FS+6d |  |  |  | 718d |  |  |
| 5 | 1.4 | 2#、4#、6#塔吊基础 | 17d | 2004-10-15 | 2004-10-31 |  |  |  |  | 693d | 0d | start no earlier than 2004-10-15 |
| 6 | 1.5 | 2#、4#、6#塔吊安装 | 18d | 2004-11-08 | 2004-11-25 | 5FS+7d |  |  |  | 693d |  |  |
| 7 | 1.6 | 现场临水施工 | 31d | 2004-10-01 | 2004-10-31 |  |  |  |  | 718d |  | start no earlier than 2004-10-01 |
| 8 | 1.7 | 现场临电施工 | 31d | 2004-10-01 | 2004-10-31 |  |  |  |  | 718d |  | start no earlier than 2004-10-01 |
| 9 | 1.8 | 现场临时设施（临建）施工 | 34d | 2004-10-08 | 2004-11-10 |  |  |  |  | 708d |  | start no earlier than 2004-10-08 |
| 11 | 2 | **总工期** | 735d | 2004-10-15 | 2006-10-19 |  | 2004-10-15 | 2006-08-10 | 665d? | 0d |  |  |
| 12 | 2.1 | 配合中冶地清土、浇筑垫层 | 11d | 2004-10-15 | 2004-10-25 |  |  |  |  | 724d |  |  |
| 13 | 2.2 | **结构施工（包括钢结构）** | 339d | 2004-10-25 | 2005-09-28 |  |  |  |  | 360d |  |  |
| 14 | 2.2.1 | **混凝土结构施工** | 277d | 2004-10-25 | 2005-07-28 |  |  |  |  | 360d |  |  |
| 15 | 2.2.1.1 | **地下室结构施工** | 168d | 2004-10-25 | 2005-04-10 |  | 2004-10-15 | 2005-02-06 | 115d | 360d |  |  |
| 16 | 2.2.1.1.1 | **基础底板施工** | 62d | 2004-10-25 | 2004-12-25 |  |  |  |  | 663d |  |  |
| 17 | 2.2.1.1.1.1 | 底板垫层、防水及保护层施工 | 27d | 2004-10-25 | 2004-11-20 |  | 2004-10-15 | 2004-11-06 | 23d | 698d |  | start no earlier than 2004-10-25 |
| 18 | 2.2.1.1.1.2 | 基础底板施工 | 41d | 2004-11-15 | 2004-12-25 |  | 2004-10-24 | 2004-12-01 | 39d | 663d |  | start no earlier than 2004-11-15 |
| 19 | 2.2.1.1.2 | 地下四层结构施工 | 31d | 2004-12-05 | 2005-01-04 |  | 2004-11-18 | 2004-12-23 | 36d | 653d |  | finish no earlier than 2005-01-04 |
| 20 | 2.2.1.1.3 | 地下三层结构施工 | 31d | 2004-12-20 | 2005-01-19 |  | 2004-12-05 | 2005-01-07 | 34d | 638d |  | start no earlier than 2004-12-20 |
| 21 | 2.2.1.1.4 | 地下二层结构施工 | 31d | 2005-01-04 | 2005-02-03 |  | 2004-12-20 | 2005-01-22 | 34d | 274d | 0d | start no earlier than 2005-01-04 |
| 22 | 2.2.1.1.5 | 春节休假 | 20d | 2005-02-04 | 2005-02-23 | 21 | 2005-02-07 | 2005-02-28 | 22d | 274d | 0d |  |
| 23 | 2.2.1.1.6 | 地下一层结构施工 | 46d | 2005-02-24 | 2005-04-10 | 22 | 2005-01-04 | 2005-02-06 | 34d | 274d | 0d |  |
| 24 | 2.2.1.2 | **地上主体结构施工** | 109d | 2005-04-11 | 2005-07-28 |  | 2004-10-15 | 2005-07-15 | 274d? | 289d |  |  |
| 25 | 2.2.1.2.1 | F01层结构施工 | 10d | 2005-04-11 | 2005-04-20 | 23 | 2005-03-01 | 2005-03-17 | 17d | 289d | 0d |  |
| 26 | 2.2.1.2.2 | F02层结构施工 | 9d | 2005-04-21 | 2005-04-29 | 25 | 2005-03-12 | 2005-03-26 | 15d | 289d | 0d |  |
| 27 | 2.2.1.2.3 | F03层结构施工 | 9d | 2005-04-30 | 2005-05-08 | 26 | 2005-03-22 | 2005-04-02 | 12d | 289d | 0d |  |
| 28 | 2.2.1.2.4 | F04层结构施工 | 8d | 2005-05-09 | 2005-05-16 | 27 | 2005-03-30 | 2005-04-13 | 15d | 289d | 0d |  |
| 29 | 2.2.1.2.5 | F05层结构施工 | 8d | 2005-05-17 | 2005-05-24 | 28 | 2005-04-09 | 2005-04-23 | 15d | 289d | 0d |  |
| 30 | 2.2.1.2.6 | F06层结构施工 | 8d | 2005-05-25 | 2005-06-01 | 29 | 2005-04-19 | 2005-05-03 | 15d | 289d | 0d |  |
| 31 | 2.2.1.2.7 | F07层结构施工 | 8d | 2005-06-02 | 2005-06-09 | 30 | 2005-04-29 | 2005-05-10 | 12d | 289d | 0d |  |
| 32 | 2.2.1.2.8 | F08层结构施工 | 8d | 2005-06-10 | 2005-06-17 | 31 | 2005-05-07 | 2005-05-18 | 12d | 289d | 0d |  |
| 33 | 2.2.1.2.9 | F09层结构施工 | 7d | 2005-06-18 | 2005-06-24 | 32 | 2005-05-15 | 2005-05-29 | 15d | 289d | 0d |  |
| 34 | 2.2.1.2.10 | F10层结构施工 | 7d | 2005-06-25 | 2005-07-01 | 33 | 2005-05-25 | 2005-06-08 | 15d | 289d | 0d |  |
| 35 | 2.2.1.2.11 | F11层结构施工 | 7d | 2005-07-02 | 2005-07-08 | 34 | 2005-06-04 | 2005-06-18 | 15d | 289d | 0d |  |
| 36 | 2.2.1.2.12 | F12层结构施工 | 7d | 2005-07-09 | 2005-07-15 | 35 | 2005-06-14 | 2005-06-28 | 15d | 289d | 0d |  |
| 37 | 2.2.1.2.13 | F13层结构施工 | 7d | 2005-07-16 | 2005-07-22 | 36 | 2005-06-24 | 2005-07-08 | 15d | 289d | 0d |  |
| 38 | 2.2.1.2.14 | 设备层结构（结构封顶） | 6d | 2005-07-23 | 2005-07-28 | 37 | 2005-07-04 | 2005-07-15 | 12d | 289d | 0d |  |

| ID | WBS | Task | Duration | Start | Finish | Predecessors | Baseline start | Baseline finish | Baseline duration | Total slack | Free slack | Constraint |
| --- | --- | --- | --- | --- | --- | --- | --- | --- | --- | --- | --- | --- |
| 40 | 2.2.2 | **钢结构工程（含验收）** | 198d | 2005-03-15 | 2005-09-28 |  | 2004-10-15 | 2004-10-15 | 0d | 386d |  |  |
| 41 | 2.2.2.1 | 钢结构构件制作 | 32d | 2005-03-15 | 2005-04-15 |  | 2005-05-04 | 2005-06-14 | 42d | 552d |  | start no earlier than 2005-03-15 |
| 42 | 2.2.2.2 | F04～F06层H～K/5～8轴和A～C/12～15轴钢桁架连桥安装 | 19d | 2005-06-18 | 2005-07-06 | 32 | 2005-06-15 | 2005-06-19 | 5d | 376d | 0d |  |
| 43 | 2.2.2.3 | F04～F06层通廊钢桁架压型钢板楼面钢筋绑扎及混凝土浇筑 | 10d | 2005-07-07 | 2005-07-16 | 42 |  |  |  | 460d |  |  |
| 44 | 2.2.2.4 | F09～设备层A～D/5～8轴和G～K/12～15轴钢桁架连桥安装 | 20d | 2005-07-29 | 2005-08-17 | 38 |  |  |  | 393d | 0d |  |
| 45 | 2.2.2.5 | F12～设备层H～J/5～8轴和B～C/12～15轴钢桁架连桥安装 | 15d | 2005-08-18 | 2005-09-01 | 44 | 2004-10-15 | 2004-10-21 | 7d | 393d | 0d | start no earlier than 2005-08-01 |
| 46 | 2.2.2.6 | F09层以上通廊钢桁架压型钢板楼面钢筋绑扎及混凝土浇筑 | 25d | 2005-08-18 | 2005-09-11 | 44 |  |  |  | 403d |  | start no earlier than 2005-07-10 |
| 47 | 2.2.2.7 | 屋面天窗钢索桁架安装 | 20d | 2005-09-02 | 2005-09-21 | 45 |  |  |  | 393d |  | start no earlier than 2005-07-10 |
| 48 | 2.2.2.8 | 钢结构防火涂料施工 | 38d | 2005-08-20 | 2005-09-26 | 42FS+20d |  |  |  | 386d | 0d | start no earlier than 2005-08-20 |
| 49 | 2.2.2.9 | 钢结构验收 | 2d | 2005-09-27 | 2005-09-28 | 48 |  |  |  | 386d |  |  |
| 51 | 2.3 | **混凝土结构验收** | 110d | 2005-04-26 | 2005-08-13 |  | 2005-02-07 | 2005-08-12 | 187d | 432d |  |  |
| 52 | 2.3.1 | 地下室结构验收 | 1d | 2005-04-26 | 2005-04-26 | 23FS+15d | 2005-02-07 | 2005-03-14 | 36d | 541d |  |  |
| 53 | 2.3.2 | F01-07层钢筋混凝土结构验收 | 1d | 2005-06-25 | 2005-06-25 | 31FS+15d | 2005-05-11 | 2005-06-07 | 28d | 481d |  |  |
| 54 | 2.3.3 | F08层以上钢筋混凝土结构验收 | 1d | 2005-08-13 | 2005-08-13 | 38FS+15d | 2005-07-16 | 2005-08-12 | 28d | 432d |  |  |
| 55 | 2.4 | **地下室外墙防水及回填土施工** | 71d | 2005-03-01 | 2005-05-10 |  | 2005-02-07 | 2005-04-02 | 55d | 527d |  |  |
| 56 | 2.4.1 | 地下室外墙防水层施工 | 42d | 2005-03-01 | 2005-04-11 |  | 2005-02-07 | 2005-03-08 | 30d | 556d |  | start no earlier than 2005-03-01 |
| 57 | 2.4.2 | 地下室外墙防水保护层及回填土施工 | 62d | 2005-03-10 | 2005-05-10 |  | 2005-02-22 | 2005-04-02 | 40d | 527d |  | start no earlier than 2005-03-10 |
| 59 | 2.5 | **粗装修施工(含湿作业)** | 200d | 2005-04-15 | 2005-10-31 |  |  |  |  | 353d |  |  |
| 60 | 2.5.1 | **地下室粗装修** | 200d | 2005-04-15 | 2005-10-31 |  | 2005-03-15 | 2005-08-31 | 170d | 353d |  |  |
| 61 | 2.5.1.1 | 地下四层地面回填、垫层施工 | 62d | 2005-04-15 | 2005-06-15 |  |  |  |  | 491d |  | start no earlier than 2005-04-15 |
| 62 | 2.5.1.2 | 地下室隔墙（砌筑、抹灰湿作业） | 91d | 2005-05-10 | 2005-08-08 |  | 2005-03-15 | 2005-04-13 | 30d | 391d | 0d | start no earlier than 2005-05-10 |
| 63 | 2.5.1.3 | 地下室顶棚腻子 | 92d | 2005-05-01 | 2005-07-31 |  | 2005-04-04 | 2005-06-02 | 60d | 445d |  | start no earlier than 2005-05-01 |
| 64 | 2.5.1.4 | 地下室墙面腻子 | 153d | 2005-06-01 | 2005-10-31 |  |  |  |  | 353d |  | start no earlier than 2005-06-01 |
| 65 | 2.5.1.5 | 地下室楼(车库)地面施工 | 78d | 2005-08-15 | 2005-10-31 |  | 2005-06-03 | 2005-08-31 | 90d | 353d |  | start no earlier than 2005-08-15 |
| 67 | 2.6 | 地上走廊轻钢龙骨隔墙工程 | 124d | 2005-07-15 | 2005-11-15 |  | 2005-06-08 | 2005-10-30 | 145d | 338d |  | start no earlier than 2005-07-15 |

| ID | WBS | Task | Duration | Start | Finish | Predecessors | Baseline start | Baseline finish | Baseline duration | Total slack | Free slack | Constraint |
| --- | --- | --- | --- | --- | --- | --- | --- | --- | --- | --- | --- | --- |
| 69 | 2.7 | **卫生间粗装修施工** | 138d | 2005-07-01 | 2005-11-15 |  |  |  |  | 338d |  |  |
| 70 | 2.7.1 | **地下室卫生间内土建专业（湿作业）** | 138d | 2005-07-01 | 2005-11-15 |  |  |  |  | 338d |  |  |
| 71 | 2.7.1.1 | 地下室卫生间内砌块墙体 | 61d | 2005-07-01 | 2005-08-30 |  |  |  |  | 369d | 31d | start no earlier than 2005-07-01 |
| 72 | 2.7.1.2 | 地下室卫生间地面防水、防水保护层 | 107d | 2005-08-01 | 2005-11-15 | 71SS | 2003-03-05 | 2003-05-23 | 80d | 338d |  | start no earlier than 2005-08-01 |
| 73 | 2.7.2 | **地上卫生间施工** | 138d | 2005-07-01 | 2005-11-15 |  |  |  |  | 338d |  |  |
| 74 | 2.7.2.1 | 卫生间F01至F05层墙体、地面防水、保护层 | 48d | 2005-07-01 | 2005-08-17 |  | 2003-03-05 | 2003-05-23 | 80d | 338d | 0d | start no earlier than 2005-07-01 |
| 75 | 2.7.2.2 | 卫生间F06至F10层墙体、地面防水、保护层 | 45d | 2005-08-18 | 2005-10-01 | 74 |  |  |  | 338d | 0d | start no earlier than 2003-07-10 |
| 76 | 2.7.2.3 | 卫生间F11至F14层墙体、地面防水、保护层 | 45d | 2005-10-02 | 2005-11-15 | 75 | 2003-03-05 | 2003-05-23 | 80d | 338d |  | start no earlier than 2003-07-20 |
| 78 | 2.8 | **幕墙工程** | 185d | 2005-05-15 | 2005-11-15 |  | 2003-04-28 | 2003-11-03 | 190d | 338d |  |  |
| 79 | 2.8.1 | 预埋件复查、转接件安装 | 61d | 2005-05-15 | 2005-07-14 |  | 2003-04-28 | 2003-05-17 | 20d | 338d | 0d | start no earlier than 2005-05-15 |
| 80 | 2.8.2 | 外立面幕墙施工（单元挂板） | 124d | 2005-07-15 | 2005-11-15 | 79 | 2003-05-16 | 2003-09-12 | 120d | 338d |  | start no earlier than 2004-08-01 |
| 81 | 2.8.3 | 中庭部分幕墙施工 | 123d | 2005-07-16 | 2005-11-15 |  |  |  |  | 338d |  | start no earlier than 2005-07-16 |
| 83 | 2.9 | **屋面工程施工** | 291d | 2005-07-29 | 2006-05-15 |  | 2005-09-02 | 2005-11-20 | 80d | 157d |  |  |
| 84 | 2.9.1 | 冷却塔、风机、卫星天线、标牌、管道等设备基础，所有穿屋面的管线、管道，避雷 | 31d | 2005-07-29 | 2005-08-28 | 38 |  |  |  | 295d | 0d |  |
| 85 | 2.9.2 | **屋面主要设备安装** | 61d | 2005-08-29 | 2005-10-28 | 84 | 2003-03-17 | 2003-05-12 | 57d | 295d | 0d |  |
| 86 | 2.9.2.1 | 冷却塔安装 | 26d | 2005-08-29 | 2005-09-23 |  |  |  |  | 295d | 0d | finish no earlier than 2003-08-18 |
| 87 | 2.9.2.2 | 冷却塔配管安装 | 30d | 2005-09-24 | 2005-10-23 | 86 |  |  |  | 295d | 0d | finish no earlier than 2003-08-20 |
| 88 | 2.9.2.3 | 冷却水系统试压及冲洗 | 5d | 2005-10-24 | 2005-10-28 | 87 |  |  |  | 295d |  | start no earlier than 2003-09-21 |
| 89 | 2.9.2.4 | 屋顶风机安装 | 20d | 2005-08-29 | 2005-09-17 |  |  |  |  | 305d | 0d | start no earlier than 2003-08-05 |
| 90 | 2.9.2.5 | 屋顶风机风管碰头安装 | 31d | 2005-09-18 | 2005-10-18 | 89 |  |  |  | 305d |  | finish no earlier than 2003-08-20 |
| 91 | 2.9.3 | 屋面保温层、找平层施工 | 31d | 2005-10-29 | 2005-11-28 | 85 | 2005-09-02 | 2005-10-01 | 30d | 295d | 0d |  |
| 92 | 2.9.4 | 屋面防水层、保护层施工 | 30d | 2005-11-29 | 2005-12-28 | 91 | 2005-09-27 | 2005-10-26 | 30d | 295d |  |  |
| 93 | 2.9.5 | 装饰面层（广场砖）施工 | 76d | 2006-03-01 | 2006-05-15 |  | 2005-10-22 | 2005-11-20 | 30d | 157d |  | start no earlier than 2006-03-01 |
| 94 | 2.10 | **擦窗机安装** | 67d | 2005-07-29 | 2005-10-03 |  | 2003-08-04 | 2003-10-22 | 80d | 381d |  |  |
| 95 | 2.10.1 | 擦窗机基础施工 | 21d | 2005-07-29 | 2005-08-18 | 38 |  |  |  | 381d | 0d | start no earlier than 2003-05-01 |
| 96 | 2.10.2 | 轨道安装 | 25d | 2005-08-19 | 2005-09-12 | 95 |  |  |  | 381d | 0d |  |
| 97 | 2.10.3 | 设备安装 | 21d | 2005-09-13 | 2005-10-03 | 96 |  |  |  | 381d |  |  |

| ID | WBS | Task | Duration | Start | Finish | Predecessors | Baseline start | Baseline finish | Baseline duration | Total slack | Free slack | Constraint |
| --- | --- | --- | --- | --- | --- | --- | --- | --- | --- | --- | --- | --- |
| 98 | 2.11 | **塔吊拆除** | 45d | 2005-09-01 | 2005-10-15 |  |  |  |  | 369d |  |  |
| 99 | 2.11.1 | 1#、3#、5#塔吊拆除 | 10d | 2005-09-01 | 2005-09-10 |  |  |  |  | 404d |  | start no earlier than 2005-09-01 |
| 100 | 2.11.2 | 2#、4#、6#塔吊拆除 | 15d | 2005-10-01 | 2005-10-15 |  |  |  |  | 369d |  | start no earlier than 2005-10-01 |
| 101 | 2.12 | **防火门安装** | 99d | 2005-08-09 | 2005-11-15 |  |  |  |  | 338d |  |  |
| 102 | 2.12.1 | 地下室防火卷帘门、钢质防火门框安装 | 63d | 2005-08-09 | 2005-10-10 | 62 |  |  |  | 374d |  | finish no earlier than 2003-07-31 |
| 103 | 2.12.2 | 地上钢质防火门和木制防火门框安装 | 93d | 2005-08-15 | 2005-11-15 |  |  |  |  | 338d |  | start no earlier than 2005-08-15 |
| 104 | 2.13 | 消防楼梯前室、楼梯间装修 | 91d | 2006-04-01 | 2006-06-30 |  |  |  |  | 111d |  | start no earlier than 2006-04-01 |
| 106 | 2.14 | 电梯工程（含调试） | 153d | 2005-08-04 | 2006-01-03 | 38FS+6d | 2003-06-23 | 2003-10-20 | 120d | 289d |  | start no earlier than 2003-06-01 |
| 108 | 2.15 | 机电预留预埋工程 | 261d | 2004-11-10 | 2005-07-28 |  |  |  |  | 448d |  | start no earlier than 2004-11-10 |
| 109 | 2.16 | **机电工程** | 728d | 2004-10-15 | 2006-10-12 |  |  |  |  | 7d |  |  |
| 110 | 2.16.1 | **地下部分** | 698d | 2004-10-15 | 2006-09-12 |  |  |  |  | 37d |  |  |
| 111 | 2.16.1.1 | 春节放假 | 22d | 2006-01-24 | 2006-02-14 |  |  |  |  | 247d |  | start no earlier than 2006-01-24 |
| 112 | 2.16.1.2 | **建筑电气** | 668d | 2004-10-15 | 2006-08-13 |  |  |  |  | 67d |  |  |
| 113 | 2.16.1.2.1 | 地下四层沿吊顶明配管敷设 | 35d | 2005-05-01 | 2005-06-04 |  |  |  |  | 67d | 0d | start no earlier than 2005-05-01 |
| 114 | 2.16.1.2.2 | 地下四层二次结构内配管 | 35d | 2005-05-11 | 2005-06-14 | 113SS+10d |  |  |  | 492d |  | start no earlier than 2005-05-11 |
| 115 | 2.16.1.2.3 | 地下四层桥架、线槽敷设 | 42d | 2005-06-10 | 2005-07-21 | 113SS+40d |  |  |  | 455d |  |  |
| 116 | 2.16.1.2.4 | 地下三层沿吊顶明配管敷设 | 35d | 2005-05-26 | 2005-06-29 | 113FS-10d |  |  |  | 67d | 0d |  |
| 117 | 2.16.1.2.5 | 地下三层二次结构内配管 | 35d | 2005-06-05 | 2005-07-09 | 116SS+10d |  |  |  | 467d |  |  |
| 118 | 2.16.1.2.6 | 地下三层桥架、线槽敷设 | 42d | 2005-06-20 | 2005-07-31 | 116SS+25d |  |  |  | 445d |  |  |
| 119 | 2.16.1.2.7 | 地下二层沿吊顶明配管敷设 | 35d | 2005-06-20 | 2005-07-24 | 116FS-10d |  |  |  | 67d | 0d |  |
| 120 | 2.16.1.2.8 | 地下二层二次结构内配管 | 35d | 2005-06-30 | 2005-08-03 | 119SS+10d |  |  |  | 442d |  |  |
| 121 | 2.16.1.2.9 | 地下二层桥架、线槽敷设 | 42d | 2005-07-10 | 2005-08-20 | 119SS+20d |  |  |  | 425d |  |  |
| 122 | 2.16.1.2.10 | 地下一层沿吊顶明配管敷设 | 40d | 2005-07-15 | 2005-08-23 | 119FS-10d |  |  |  | 67d | 0d |  |
| 123 | 2.16.1.2.11 | 地下一层二次结构内配管 | 40d | 2005-07-25 | 2005-09-02 | 122SS+10d |  |  |  | 412d |  |  |
| 124 | 2.16.1.2.12 | 地下一层桥架、线槽敷设 | 50d | 2005-08-14 | 2005-10-02 | 122SS+30d |  |  |  | 67d | 0d |  |
| 125 | 2.16.1.2.13 | 等电位安装 | 60d | 2004-10-15 | 2004-12-13 |  |  |  |  | 675d |  |  |
| 126 | 2.16.1.2.14 | 配电箱体安装 | 95d | 2005-09-13 | 2005-12-16 | 124FS-20d |  |  |  | 307d |  |  |
| 127 | 2.16.1.2.15 | 竖井内桥架、线槽敷设 | 60d | 2005-10-03 | 2005-12-01 | 124 |  |  |  | 67d | 0d |  |
| 128 | 2.16.1.2.16 | 电缆、电线敷设 | 145d | 2005-10-18 | 2006-03-11 | 127SS+15d |  |  |  | 67d | 0d |  |
| 129 | 2.16.1.2.17 | 线路并线、配电箱柜接线及电缆压接 | 95d | 2006-01-11 | 2006-04-15 | 128FS-60d |  |  |  | 67d | 0d |  |
| 130 | 2.16.1.2.18 | 插接母线安装 | 75d | 2006-01-11 | 2006-03-26 | 129SS |  |  |  | 207d |  |  |
| 131 | 2.16.1.2.19 | 线路绝缘摇测 | 30d | 2006-04-16 | 2006-05-15 | 129 |  |  |  | 67d | 0d |  |
| 132 | 2.16.1.2.20 | 电气末端设备安装 | 90d | 2006-04-26 | 2006-07-24 | 131SS+10d |  |  |  | 67d | 0d |  |
| 133 | 2.16.1.2.21 | 系统调试 | 20d | 2006-07-25 | 2006-08-13 | 132 |  |  |  | 67d |  |  |

| ID | WBS | Task | Duration | Start | Finish | Predecessors | Total slack | Free slack | Constraint |
| --- | --- | --- | --- | --- | --- | --- | --- | --- | --- |
| 134 | 2.16.1.3 | **通风、空调** | 500d | 2005-05-01 | 2006-09-12 |  | 37d |  |  |
| 135 | 2.16.1.3.1 | 风管制作 | 234d | 2005-05-01 | 2005-12-20 |  | 38d | 0d | finish no earlier than 2005-12-20 |
| 136 | 2.16.1.3.2 | 地下四层水平风管安装 | 60d | 2005-05-21 | 2005-07-19 | 135SS+20d | 37d | 0d | start no earlier than 2005-05-01 |
| 137 | 2.16.1.3.3 | 地下三层水平风管安装 | 60d | 2005-07-10 | 2005-09-07 | 136FS-10d | 37d | 0d |  |
| 138 | 2.16.1.3.4 | 地下二层水平风管安装 | 60d | 2005-08-29 | 2005-10-27 | 137FS-10d | 37d | 0d |  |
| 139 | 2.16.1.3.5 | 地下一层水平风管安装 | 80d | 2005-10-18 | 2006-01-05 | 135FF+15d, 138FS-10d | 37d | 0d |  |
| 140 | 2.16.1.3.6 | 空调机组安装 | 30d | 2005-10-18 | 2005-11-16 | 139SS | 337d |  |  |
| 141 | 2.16.1.3.7 | 风机、诱导风机安装 | 60d | 2006-01-06 | 2006-03-06 | 139 | 37d | 0d |  |
| 142 | 2.16.1.3.8 | 地下三层空调水主管安装 | 45d | 2005-07-30 | 2005-09-12 | 137SS+20d | 37d | 0d |  |
| 143 | 2.16.1.3.9 | 空调水立管安装 | 45d | 2005-09-13 | 2005-10-27 | 142 | 37d | 0d |  |
| 144 | 2.16.1.3.10 | 地下一层空调水平主管安装 | 40d | 2005-10-28 | 2005-12-06 | 143 | 37d | 0d |  |
| 145 | 2.16.1.3.11 | 风机盘管安装 | 20d | 2005-12-07 | 2005-12-26 | 144 | 37d | 0d |  |
| 146 | 2.16.1.3.12 | 地下一层空调支管安装 | 70d | 2005-12-27 | 2006-03-06 | 145 | 37d | 0d |  |
| 147 | 2.16.1.3.13 | 风机、空调机组阀部件安装及接口 | 60d | 2006-03-07 | 2006-05-05 | 141, 146 | 37d | 0d |  |
| 148 | 2.16.1.3.14 | 风管及水管试验、冲洗 | 180d | 2005-11-07 | 2006-05-05 | 136SS+10d, 147FF | 37d | 0d |  |
| 149 | 2.16.1.3.15 | 风管、水管保温 | 50d | 2006-05-06 | 2006-06-24 | 148 | 37d | 0d |  |
| 150 | 2.16.1.3.16 | 末端安装 | 60d | 2006-06-25 | 2006-08-23 | 149 | 37d | 0d |  |
| 151 | 2.16.1.3.17 | 系统调试 | 20d | 2006-08-24 | 2006-09-12 | 150 | 37d |  |  |
| 152 | 2.16.1.4 | **给排水** | 500d | 2004-10-15 | 2006-02-26 |  | 235d |  |  |
| 153 | 2.16.1.4.1 | 地下室雨水、污水、废水管道安装 | 120d | 2004-10-15 | 2005-02-11 |  | 235d | 0d |  |
| 154 | 2.16.1.4.2 | 地下室给水、中水管道安装 | 30d | 2005-02-12 | 2005-03-13 | 153 | 295d | 0d |  |
| 155 | 2.16.1.4.3 | 地下室直饮水管道安装 | 30d | 2005-02-12 | 2005-03-13 | 153 | 243d | 0d |  |
| 156 | 2.16.1.4.4 | 污水泵安装及接管 | 120d | 2005-03-04 | 2005-07-01 | 155FS-10d | 243d | 8d |  |
| 157 | 2.16.1.4.5 | 地下四层暖气主管道安装 | 30d | 2005-02-22 | 2005-03-23 | 154FS-20d | 295d | 0d |  |
| 158 | 2.16.1.4.6 | 地下四层暖气片及支管安装 | 30d | 2005-03-24 | 2005-04-22 | 157 | 295d | 0d |  |
| 159 | 2.16.1.4.7 | 地下三层暖气主管道安装 | 30d | 2005-04-23 | 2005-05-22 | 158 | 295d | 0d |  |
| 160 | 2.16.1.4.8 | 地下三层暖气片及支管安装 | 40d | 2005-05-23 | 2005-07-01 | 159 | 295d | 0d |  |
| 161 | 2.16.1.4.9 | 地下二层暖气主管道安装 | 40d | 2005-07-02 | 2005-08-10 | 160 | 295d | 0d |  |
| 162 | 2.16.1.4.10 | 地下二层暖气片及支管安装 | 30d | 2005-08-11 | 2005-09-09 | 161 | 295d | 60d |  |
| 163 | 2.16.1.4.11 | 地下四层消火栓主管及环管安装 | 20d | 2004-10-15 | 2004-11-03 | 153SS | 235d | 0d |  |
| 164 | 2.16.1.4.12 | 地下四层喷洒主支管安装 | 80d | 2004-10-25 | 2005-01-12 | 163FS-10d | 235d | 0d |  |
| 165 | 2.16.1.4.13 | 地下三层消火栓主管及环管安装 | 20d | 2005-01-13 | 2005-02-01 | 164 | 235d | 0d |  |
| 166 | 2.16.1.4.14 | 地下三层喷洒主支管安装 | 80d | 2005-01-23 | 2005-04-12 | 165FS-10d | 235d | 0d |  |
| 167 | 2.16.1.4.15 | 地下二层消火栓主管及环管安装 | 20d | 2005-04-13 | 2005-05-02 | 166 | 235d | 0d |  |
| 168 | 2.16.1.4.16 | 地下二层喷洒主支管安装 | 90d | 2005-04-23 | 2005-07-21 | 167FS-10d | 235d | 0d |  |
| 169 | 2.16.1.4.17 | 地下一层消火栓主管及环管安装 | 40d | 2005-07-22 | 2005-08-30 | 168 | 235d | 0d |  |
| 170 | 2.16.1.4.18 | 地下一层喷洒主支管安装 | 80d | 2005-08-21 | 2005-11-08 | 169FS-10d | 235d | 0d |  |
| 171 | 2.16.1.4.19 | 消防箱安装及配管 | 60d | 2005-01-13 | 2005-03-13 | 164 | 465d | 0d |  |
| 172 | 2.16.1.4.20 | 报警组阀部件安装 | 25d | 2005-03-14 | 2005-04-07 | 171 | 465d | 0d |  |
| 173 | 2.16.1.4.21 | 水管试压、冲洗 | 260d | 2005-02-22 | 2005-11-08 | 153SS+20d, 162FF, 170FF, 172FF-15d | 235d | 0d |  |
| 174 | 2.16.1.4.22 | 水管保温 | 120d | 2005-08-11 | 2005-12-08 | 173FS-90d | 235d | 0d |  |
| 175 | 2.16.1.4.23 | 卫生洁具安装 | 110d | 2005-08-31 | 2005-12-18 | 156FS+52d, 174FS-100d | 235d | 0d |  |
| 176 | 2.16.1.4.24 | 末端安装 | 60d | 2005-12-09 | 2006-02-06 | 175FS-10d | 235d | 0d |  |
| 177 | 2.16.1.4.25 | 系统调试 | 20d | 2006-02-07 | 2006-02-26 | 176 | 235d |  |  |

| ID | WBS | Task | Duration | Start | Finish | Predecessors | Total slack | Free slack | Constraint |
| --- | --- | --- | --- | --- | --- | --- | --- | --- | --- |
| 178 | 2.16.1.5 | **智能建筑** | 470d | 2004-10-15 | 2006-01-27 |  | 172d |  |  |
| 179 | 2.16.1.5.1 | 地下四层沿吊顶明配管敷设 | 35d | 2004-10-15 | 2004-11-18 |  | 220d | 0d |  |
| 180 | 2.16.1.5.2 | 地下四层二次结构内配管 | 35d | 2004-10-25 | 2004-11-28 | 179SS+10d | 690d |  |  |
| 181 | 2.16.1.5.3 | 地下四层桥架、线槽敷设 | 42d | 2004-11-24 | 2005-01-04 | 179SS+40d | 653d |  |  |
| 182 | 2.16.1.5.4 | 地下三层沿吊顶明配管敷设 | 35d | 2004-11-09 | 2004-12-13 | 179FS-10d | 220d | 0d |  |
| 183 | 2.16.1.5.5 | 地下三层二次结构内配管 | 35d | 2004-11-19 | 2004-12-23 | 182SS+10d | 665d |  |  |
| 184 | 2.16.1.5.6 | 地下三层桥架、线槽敷设 | 42d | 2004-12-04 | 2005-01-14 | 182SS+25d | 643d |  |  |
| 185 | 2.16.1.5.7 | 地下二层沿吊顶明配管敷设 | 35d | 2004-12-04 | 2005-01-07 | 182FS-10d | 220d | 0d |  |
| 186 | 2.16.1.5.8 | 地下二层二次结构内配管 | 35d | 2004-12-14 | 2005-01-17 | 185SS+10d | 640d |  |  |
| 187 | 2.16.1.5.9 | 地下二层桥架、线槽敷设 | 42d | 2005-03-19 | 2005-04-29 | 191SS+20d | 538d |  |  |
| 188 | 2.16.1.5.10 | 地下一层沿吊顶明配管敷设 | 40d | 2004-12-29 | 2005-02-06 | 185FS-10d | 220d | 0d |  |
| 189 | 2.16.1.5.11 | 地下一层二次结构内配管 | 40d | 2005-01-08 | 2005-02-16 | 188SS+10d | 610d |  |  |
| 190 | 2.16.1.5.12 | 地下一层桥架、线槽敷设 | 50d | 2005-01-28 | 2005-03-18 | 188SS+30d | 220d | 0d |  |
| 191 | 2.16.1.5.13 | 箱体安装 | 90d | 2005-02-27 | 2005-05-27 | 190FS-20d | 510d | 0d |  |
| 192 | 2.16.1.5.14 | 竖井内桥架、线槽敷设 | 65d | 2005-03-19 | 2005-05-22 | 190 | 220d | 0d |  |
| 193 | 2.16.1.5.15 | 线缆敷设 | 90d | 2005-04-03 | 2005-07-01 | 192SS+15d | 265d | 0d |  |
| 194 | 2.16.1.5.16 | 箱体接线 | 90d | 2005-05-03 | 2005-07-31 | 193FS-60d | 265d | 0d |  |
| 195 | 2.16.1.5.17 | 系统末端设备安装 | 90d | 2005-08-01 | 2005-10-29 | 194 | 265d | 0d |  |
| 196 | 2.16.1.5.18 | 系统调试 | 90d | 2005-10-30 | 2006-01-27 | 195 | 265d |  |  |
| 197 | 2.16.2 | **地上部分** | 648d | 2004-10-15 | 2006-07-24 |  | 87d |  |  |
| 198 | 2.16.2.1 | **建筑电气** | 500d | 2004-10-15 | 2006-02-26 |  | 222d |  |  |
| 199 | 2.16.2.1.1 | 1－7层吊顶内明配管敷设 | 85d | 2004-10-15 | 2005-01-07 |  | 270d | 0d |  |
| 200 | 2.16.2.1.2 | 1－7层配合二次结构配管 | 85d | 2004-10-25 | 2005-01-17 | 199SS+10d | 620d | 0d |  |
| 201 | 2.16.2.1.3 | 1－7层水平桥架、线槽敷设 | 95d | 2004-11-04 | 2005-02-06 | 200SS+10d | 620d |  |  |
| 202 | 2.16.2.1.4 | 8－14层吊顶内明配管敷设 | 80d | 2004-12-14 | 2005-03-03 | 199SS+60d | 270d | 0d |  |
| 203 | 2.16.2.1.5 | 8-14层配合二次结构配管 | 80d | 2004-12-24 | 2005-03-13 | 202SS+10d | 270d | 0d |  |
| 204 | 2.16.2.1.6 | 8－14层水平桥架、线槽敷设 | 90d | 2005-01-03 | 2005-04-02 | 203SS+10d | 270d | 50d |  |
| 205 | 2.16.2.1.7 | 竖井内桥架、线槽、插接母线敷设 | 75d | 2005-05-23 | 2005-08-05 | 192, 204 | 220d | 0d |  |
| 206 | 2.16.2.1.8 | 屋顶防雷接地安装 | 45d | 2005-09-20 | 2005-11-03 |  | 350d |  | start no earlier than 2005-09-20 |
| 207 | 2.16.2.1.9 | 配电箱体安装 | 100d | 2005-06-22 | 2005-09-29 | 205FS-45d | 220d | 0d |  |
| 208 | 2.16.2.1.10 | 电缆、电线敷设 | 100d | 2005-07-12 | 2005-10-19 | 207SS+20d | 220d | 0d |  |
| 209 | 2.16.2.1.11 | 线路并线、配电箱柜接线及电缆压接 | 80d | 2005-08-26 | 2005-11-13 | 208SS+45d | 220d | 0d |  |
| 210 | 2.16.2.1.12 | 线路绝缘摇测 | 20d | 2005-11-14 | 2005-12-03 | 209 | 220d | 0d |  |
| 211 | 2.16.2.1.13 | 电气末端设备安装 | 90d | 2005-11-19 | 2006-02-16 | 210SS+5d | 220d | 0d |  |
| 212 | 2.16.2.1.14 | 系统调试 | 10d | 2006-02-17 | 2006-02-26 | 211 | 220d | 0d |  |

| ID | WBS | Task | Duration | Start | Finish | Predecessors | Total slack | Free slack | Constraint |
| --- | --- | --- | --- | --- | --- | --- | --- | --- | --- |
| 213 | 2.16.2.2 | **通风空调** | 648d | 2004-10-15 | 2006-07-24 |  | 87d |  |  |
| 214 | 2.16.2.2.1 | 风管制作 | 350d | 2004-10-15 | 2005-09-29 |  | 285d | 0d |  |
| 215 | 2.16.2.2.2 | 1－7层水平风管安装 | 240d | 2004-11-04 | 2005-07-01 | 214SS+20d | 325d | 0d |  |
| 216 | 2.16.2.2.3 | 1－7层空调水管敷设 | 120d | 2004-11-24 | 2005-03-23 | 215SS+20d | 325d | 0d |  |
| 217 | 2.16.2.2.4 | 1－7层VAV、CAV末端设备安装 | 90d | 2004-12-24 | 2005-03-23 | 216SS+30d | 495d | 10d |  |
| 218 | 2.16.2.2.5 | 1－7层空调水支管安装 | 110d | 2005-03-04 | 2005-06-21 | 216FS-20d, 217SS+60d | 485d |  |  |
| 219 | 2.16.2.2.6 | 8－14层水平风管安装 | 220d | 2005-11-17 | 2006-06-24 | 139FS-50d, 214FF+20d | 117d |  | finish no earlier than 2006-02-04 |
| 220 | 2.16.2.2.7 | 8－14层空调水管敷设 | 110d | 2006-01-16 | 2006-05-05 | 146FS-50d | 107d | 0d | finish no earlier than 2005-11-11 |
| 221 | 2.16.2.2.8 | 8－14层VAV、CAV末端设备安装 | 90d | 2006-02-15 | 2006-05-15 | 220SS+30d | 157d | 0d | finish no earlier than 2005-12-11 |
| 222 | 2.16.2.2.9 | 8－14层空调水支管安装 | 90d | 2006-04-16 | 2006-07-14 | 220FS-40d, 221SS+60d | 87d | 0d | finish no earlier than 2006-02-04 |
| 223 | 2.16.2.2.10 | 通风立管及空调水立管安装 | 60d | 2004-10-15 | 2004-12-13 |  | 480d | 0d |  |
| 224 | 2.16.2.2.11 | 屋顶冷却塔配管 | 90d | 2004-12-29 | 2005-03-28 | 223FS+15d | 480d | 0d |  |
| 225 | 2.16.2.2.12 | 风机及空调机组安装 | 60d | 2005-01-28 | 2005-03-28 | 224SS+30d | 480d | 0d |  |
| 226 | 2.16.2.2.13 | 设备接口 | 90d | 2005-03-29 | 2005-06-26 | 225 | 480d |  |  |
| 227 | 2.16.2.2.14 | 末端安装 | 190d | 2005-06-12 | 2005-12-18 | 214SS+240d | 285d | 0d |  |
| 228 | 2.16.2.2.15 | 空调风管、水管保温 | 120d | 2006-03-27 | 2006-07-24 | 215, 222FF+10d | 87d |  |  |
| 229 | 2.16.2.2.16 | 空调水管试验、冲洗 | 350d | 2005-08-01 | 2006-07-16 | 216SS+20d, 222FF+2d | 95d |  |  |
| 230 | 2.16.2.2.17 | 系统调试 | 20d | 2005-12-19 | 2006-01-07 | 227 | 285d |  |  |
| 231 | 2.16.2.3 | **给排水** | 450d | 2004-10-15 | 2006-01-07 |  | 222d |  |  |
| 232 | 2.16.2.3.1 | 雨水管道安装 | 90d | 2004-10-15 | 2005-01-12 |  | 255d | 0d |  |
| 233 | 2.16.2.3.2 | 污、废水管道安装 | 240d | 2004-10-15 | 2005-06-11 | 232SS | 406d | 0d |  |
| 234 | 2.16.2.3.3 | 1－7层冷、热水、中水管道安装 | 120d | 2005-01-13 | 2005-05-12 | 232 | 255d | 0d |  |
| 235 | 2.16.2.3.4 | 1-7层直饮水管道安装 | 120d | 2005-01-13 | 2005-05-12 | 234SS | 525d |  |  |
| 236 | 2.16.2.3.5 | 1-7层消火栓主、立管安装 | 150d | 2004-10-15 | 2005-03-13 | 232SS | 505d | 0d |  |
| 237 | 2.16.2.3.6 | 1-7层消防箱安装及配管 | 90d | 2005-03-04 | 2005-06-01 | 236FS-10d | 505d |  |  |
| 238 | 2.16.2.3.7 | 1-7层喷洒主支管安装 | 240d | 2004-10-15 | 2005-06-11 | 232SS | 390d | 0d |  |
| 239 | 2.16.2.3.8 | 8－14层冷、热水、中水管道安装 | 90d | 2005-05-03 | 2005-07-31 | 234FS-10d | 255d | 0d |  |
| 240 | 2.16.2.3.9 | 8-14层直饮水管道安装 | 90d | 2005-05-03 | 2005-07-31 | 239SS | 435d | 0d |  |
| 241 | 2.16.2.3.10 | 管道保温 | 90d | 2005-05-13 | 2005-08-10 | 234, 239FF+10d, 240FF+10d | 435d |  |  |
| 242 | 2.16.2.3.11 | 8-14层消火栓主、立管安装 | 90d | 2005-05-28 | 2005-08-25 | 238FS-15d | 390d | 0d |  |
| 243 | 2.16.2.3.12 | 8-14层消防箱安装及配管 | 90d | 2005-06-27 | 2005-09-24 | 242SS+30d | 390d |  |  |
| 244 | 2.16.2.3.13 | 8-14层喷洒主支管安装 | 230d | 2005-05-03 | 2005-12-18 | 239SS | 255d | 0d |  |
| 245 | 2.16.2.3.14 | 水管试压、冲洗 | 410d | 2004-11-04 | 2005-12-18 | 232SS+20d, 244FF | 255d | 0d |  |
| 246 | 2.16.2.3.15 | 卫生洁具安装 | 120d | 2005-06-02 | 2005-09-29 | 233FS-31d, 234FS+20d | 385d |  |  |
| 247 | 2.16.2.3.16 | 末端安装 | 170d | 2005-07-02 | 2005-12-18 | 244SS+60d, 245FF | 255d | 0d |  |
| 248 | 2.16.2.3.17 | 系统调试 | 20d | 2005-12-19 | 2006-01-07 | 247 | 255d | 50d |  |

| ID | WBS | Task | Duration | Start | Finish | Predecessors | Total slack | Free slack | Constraint |
| --- | --- | --- | --- | --- | --- | --- | --- | --- | --- |
| 249 | 2.16.2.4 | **智能建筑** | 500d | 2004-10-15 | 2006-02-26 |  | 235d |  |  |
| 250 | 2.16.2.4.1 | 1－7层吊顶内明配管敷设 | 85d | 2004-10-15 | 2005-01-07 |  | 565d | 0d |  |
| 251 | 2.16.2.4.2 | 1－7层配合二次结构配管 | 85d | 2004-10-25 | 2005-01-17 | 250SS+10d | 620d | 0d |  |
| 252 | 2.16.2.4.3 | 1－7层水平桥架、线槽敷设 | 95d | 2004-11-04 | 2005-02-06 | 251SS+10d | 620d |  |  |
| 253 | 2.16.2.4.4 | 8－14层吊顶内明配管敷设 | 80d | 2004-12-14 | 2005-03-03 | 250SS+60d | 565d | 0d |  |
| 254 | 2.16.2.4.5 | 8-14层配合二次结构配管 | 80d | 2004-12-24 | 2005-03-13 | 253SS+10d | 565d | 0d |  |
| 255 | 2.16.2.4.6 | 8－14层水平桥架、线槽敷设 | 90d | 2005-01-03 | 2005-04-02 | 254SS+10d | 565d |  |  |
| 256 | 2.16.2.4.7 | 竖井内桥架、线槽敷设 | 70d | 2005-05-23 | 2005-07-31 | 192 | 220d | 0d |  |
| 257 | 2.16.2.4.8 | 箱体安装 | 45d | 2005-04-08 | 2005-05-22 | 256SS-45d | 515d |  |  |
| 258 | 2.16.2.4.9 | 电缆、电线敷设 | 100d | 2005-08-01 | 2005-11-08 | 256 | 220d | 0d |  |
| 259 | 2.16.2.4.10 | 箱柜接线 | 75d | 2005-09-20 | 2005-12-03 | 258SS+50d | 320d |  |  |
| 260 | 2.16.2.4.11 | 系统末端设备安装 | 110d | 2005-09-10 | 2005-12-28 | 258SS+40d | 220d | 0d |  |
| 261 | 2.16.2.4.12 | 系统调试 | 60d | 2005-12-29 | 2006-02-26 | 260 | 220d | 0d |  |
| 262 | 2.16.3 | **各机房设备安装** | 274d | 2005-08-15 | 2006-05-15 |  | 157d |  |  |
| 263 | 2.16.3.1 | 冷却塔安装 | 30d | 2005-08-15 | 2005-09-13 |  | 401d |  | start no earlier than 2005-08-15 |
| 264 | 2.16.3.2 | 热力站设备及管道安装 | 90d | 2005-08-15 | 2005-11-12 |  | 341d |  | start no earlier than 2005-08-15 |
| 265 | 2.16.3.3 | 冷冻站设备及管道安装 | 120d | 2005-10-01 | 2006-01-28 |  | 264d |  | start no earlier than 2005-10-01 |
| 266 | 2.16.3.4 | 变配电室设备安装 | 66d | 2005-08-15 | 2005-10-19 |  | 365d |  | start no earlier than 2005-08-15 |
| 267 | 2.16.3.5 | 弱电各机房设备安装 | 135d | 2006-01-01 | 2006-05-15 |  | 157d |  | start no earlier than 2006-01-01 |
| 268 | 2.16.3.6 | 消防泵房设备及管道安装 | 60d | 2005-10-15 | 2005-12-13 |  | 310d |  | start no earlier than 2005-10-15 |
| 269 | 2.16.3.7 | 各类水泵房设备及管道安装 | 90d | 2005-11-01 | 2006-01-29 |  | 263d |  | start no earlier than 2005-11-01 |
| 270 | 2.16.4 | **深化设计** | 200d | 2005-04-11 | 2005-10-27 |  | 357d |  |  |
| 271 | 2.16.4.1 | 地下部分机电综合留洞图 | 60d | 2005-04-11 | 2005-06-09 |  | 357d | 0d | start no earlier than 2005-04-11 |
| 272 | 2.16.4.2 | 地上部分机电综合留洞图 | 100d | 2005-06-10 | 2005-09-17 | 271 | 397d |  |  |
| 273 | 2.16.4.3 | 地下部分机电管线综合图 | 120d | 2005-04-21 | 2005-08-18 | 271SS+10d | 357d | 0d |  |
| 274 | 2.16.4.4 | 地上部分机电管线综合图 | 140d | 2005-06-10 | 2005-10-27 | 271 | 357d |  |  |
| 275 | 2.16.4.5 | 机电专业机房详图 | 120d | 2005-06-30 | 2005-10-27 | 273SS+70d | 357d |  |  |

| ID | WBS | Task | Duration | Start | Finish | Predecessors | Total slack | Free slack | Constraint |
| --- | --- | --- | --- | --- | --- | --- | --- | --- | --- |
| 276 | 2.16.5 | **电梯** | 378d | 2005-08-31 | 2006-09-12 |  | 37d |  |  |
| 277 | 2.16.5.1 | 各核心筒电梯安装 | 120d | 2005-08-31 | 2005-12-28 |  | 295d |  | start no earlier than 2005-08-31 |
| 278 | 2.16.5.2 | 扶梯安装 | 24d | 2006-07-02 | 2006-07-25 |  | 25d | 0d | start no earlier than 2006-07-02 |
| 279 | 2.16.5.3 | 中庭观光梯安装 | 29d | 2006-07-26 | 2006-08-23 | 278 | 25d | 0d |  |
| 280 | 2.16.5.4 | 电梯调试 | 20d | 2006-08-24 | 2006-09-12 | 279 | 25d | 0d |  |
| 281 | 2.16.6 | **室外市政管线及水景** | 386d | 2005-09-01 | 2006-09-21 |  | 28d |  |  |
| 282 | 2.16.6.1 | 电力管线 | 30d | 2005-09-01 | 2005-09-30 |  | 384d |  | start no earlier than 2005-09-01 |
| 283 | 2.16.6.2 | 雨污水管线 | 61d | 2005-10-15 | 2005-12-14 |  | 309d |  | start no earlier than 2005-10-15 |
| 284 | 2.16.6.3 | 自来水、中水管线（含消防及中水） | 31d | 2006-03-01 | 2006-03-31 |  | 202d |  | start no earlier than 2006-03-01 |
| 285 | 2.16.6.4 | 热力管线 | 40d | 2006-04-15 | 2006-05-24 |  | 148d |  | start no earlier than 2006-04-15 |
| 286 | 2.16.6.5 | 燃气管线 | 40d | 2006-06-09 | 2006-07-18 |  | 93d |  | start no earlier than 2006-06-09 |
| 287 | 2.16.6.6 | 电信管线 | 25d | 2006-07-19 | 2006-08-12 |  | 68d |  | start no earlier than 2006-07-19 |
| 288 | 2.16.6.7 | 景观照明 | 40d | 2006-08-13 | 2006-09-21 |  | 28d |  | start no earlier than 2006-08-13 |
| 289 | 2.16.6.8 | 水景施工 | 150d | 2006-02-20 | 2006-07-19 |  | 92d |  | start no earlier than 2006-02-20 |
| 290 | 2.16.7 | 机电联合调试 | 30d | 2006-09-13 | 2006-10-12 | 248 | 7d |  | start no earlier than 2006-09-13 |
| 291 | 2.16.8 | **机电验收** | 63d | 2006-02-27 | 2006-04-30 |  | 172d |  |  |
| 292 | 2.16.8.1 | 消防工程验收 | 63d | 2006-02-27 | 2006-04-30 | 212, 248, 261 | 172d |  |  |
| 294 | 2.17 | **精装修工程** | 380d | 2005-09-01 | 2006-09-15 |  | 34d |  |  |
| 295 | 2.17.1 | **卫生间装修** | 318d | 2005-09-01 | 2006-07-15 |  | 96d |  |  |
| 296 | 2.17.1.1 | 卫生间装修样板间施工 | 30d | 2005-09-01 | 2005-09-30 |  | 174d | 0d | start no earlier than 2005-09-01 |
| 297 | 2.17.1.2 | F01-F07层卫生间墙面砖粘贴 | 90d | 2005-10-01 | 2005-12-29 |  | 140d | 0d | start no earlier than 2005-10-01 |
| 298 | 2.17.1.3 | F08-F14层卫生间墙面砖粘贴 | 154d | 2005-12-30 | 2006-06-01 | 297 | 140d |  |  |
| 299 | 2.17.1.4 | 地面砖铺贴 | 152d | 2005-12-15 | 2006-05-15 | 297SS+3d | 157d |  | start no earlier than 2005-12-15 |
| 300 | 2.17.1.5 | 灯箱、台盆架制作、装修 | 91d | 2005-10-15 | 2006-01-13 | 297SS+14d | 279d |  |  |
| 301 | 2.17.1.6 | 天花吊顶排布 | 90d | 2005-10-16 | 2006-01-13 | 297SS+15d | 279d |  |  |
| 302 | 2.17.1.7 | 卫生洁具安装 | 89d | 2006-04-01 | 2006-06-28 |  | 113d |  | start no earlier than 2006-04-01 |
| 303 | 2.17.1.8 | 木门制作安装、油漆 | 212d | 2005-10-01 | 2006-04-30 | 296 | 172d |  |  |
| 304 | 2.17.1.9 | 五金安装 | 92d | 2006-04-15 | 2006-07-15 |  | 96d |  | start no earlier than 2006-04-15 |

| ID | WBS | Task | Duration | Start | Finish | Predecessors | Baseline start | Baseline finish | Baseline duration | Total slack | Free slack | Constraint |
| --- | --- | --- | --- | --- | --- | --- | --- | --- | --- | --- | --- | --- |
| 305 | 2.17.2 | **电梯厅、走廊** | 380d | 2005-09-01 | 2006-09-15 |  |  |  |  | 34d |  |  |
| 306 | 2.17.2.1 | 样板施工 | 30d | 2005-09-01 | 2005-09-30 |  |  |  |  | 111d | 0d | start no earlier than 2005-09-01 |
| 307 | 2.17.2.2 | 石材、铝板或木作排版放线 | 60d | 2005-10-01 | 2005-11-29 | 306 |  |  |  | 111d | 0d |  |
| 308 | 2.17.2.3 | 墙面钢架制作、挂件安装 | 120d | 2005-10-16 | 2006-02-12 | 307SS+15d |  |  |  | 172d | 0d | start no earlier than 2005-08-01 |
| 309 | 2.17.2.4 | 墙面石材干挂 | 182d | 2005-10-31 | 2006-04-30 | 308SS+15d |  |  |  | 172d |  | start no earlier than 2003-07-28 |
| 310 | 2.17.2.5 | 顶棚龙骨排布 | 182d | 2005-10-01 | 2006-03-31 | 307SS |  |  |  | 111d | 0d | start no earlier than 2003-07-27 |
| 311 | 2.17.2.6 | 顶棚施工 | 243d | 2005-10-31 | 2006-06-30 | 310SS+30d |  |  |  | 111d |  | start no earlier than 2003-07-27 |
| 312 | 2.17.2.7 | 走廊墙面批腻子 | 188d | 2005-10-15 | 2006-04-20 |  |  |  |  | 182d |  | start no earlier than 2005-10-15 |
| 313 | 2.17.2.8 | 地面石材 | 181d | 2005-11-01 | 2006-04-30 |  |  |  |  | 172d |  | start no earlier than 2005-11-01 |
| 314 | 2.17.2.9 | 踢脚安装 | 150d | 2005-11-01 | 2006-03-30 |  |  |  |  | 203d |  | start no earlier than 2005-11-01 |
| 315 | 2.17.2.10 | 墙面乳胶漆 | 199d | 2006-03-01 | 2006-09-15 |  |  |  |  | 34d |  | start no earlier than 2006-03-01 |
| 316 | 2.17.3 | **办公区部分装修** | 334d | 2005-09-01 | 2006-07-31 |  |  |  |  | 80d |  |  |
| 317 | 2.17.3.1 | 样板施工 | 31d | 2005-09-01 | 2005-10-01 |  |  |  |  | 383d |  | start no earlier than 2005-09-01 |
| 318 | 2.17.3.2 | F01-F07层墙面腻子、涂料 | 182d | 2005-10-01 | 2006-03-31 |  |  |  |  | 202d |  | start no earlier than 2005-10-01 |
| 319 | 2.17.3.3 | F08-F14层墙面腻子、涂料 | 153d | 2006-03-01 | 2006-07-31 |  |  |  |  | 80d |  | start no earlier than 2006-03-01 |
| 320 | 2.17.4 | **会议室、多功能厅等特殊房间内装修** | 304d | 2005-11-01 | 2006-08-31 |  |  |  |  | 49d |  |  |
| 321 | 2.17.4.1 | 样板施工 | 45d | 2005-11-01 | 2005-12-15 |  |  |  |  | 49d | 0d | start no earlier than 2005-11-01 |
| 322 | 2.17.4.2 | 装修施工 | 259d | 2005-12-16 | 2006-08-31 | 321 |  |  |  | 49d |  |  |
| 324 | 2.18 | **工程验收** | 102d | 2006-07-10 | 2006-10-19 |  | 2006-06-27 | 2006-08-10 | 45d | 0d |  |  |
| 325 | 2.18.1 | 人防质检站验收 | 16d | 2006-07-10 | 2006-07-25 |  |  |  |  | 86d |  | start no earlier than 2006-07-10 |
| 326 | 2.18.2 | 规划验收 | 10d | 2006-09-01 | 2006-09-10 |  |  |  |  | 39d |  | start no earlier than 2006-09-01 |
| 327 | 2.18.3 | 室内环境检测（环保验收） | 11d | 2006-09-15 | 2006-09-25 |  |  |  |  | 24d |  | start no earlier than 2006-09-15 |
| 328 | 2.18.4 | 给水系统水质化验 | 15d | 2006-08-01 | 2006-08-15 |  |  |  |  | 65d |  | start no earlier than 2006-08-01 |
| 329 | 2.18.5 | 竣工清理 | 38d | 2006-09-01 | 2006-10-08 |  |  |  |  | 11d |  | start no earlier than 2006-09-01 |
| 330 | 2.18.6 | 整体工程竣工验收 | 11d | 2006-10-09 | 2006-10-19 |  |  |  |  | 0d |  | start no earlier than 2006-10-09 |
